# Сопроводительный файл

Schedule from MS Project, 2002-01-10 to 2002-04-30, status date 2002-02-10, costs in $, A marks actual dates.
MS Project 2002
Создание отчета о задачах. Настройка подробностей.

## Calendars

- Standard: Mon-Thu 09:00-12:00, 13:00-18:00; Fri 08:00-12:00, 13:00-17:00; Sat-Sun off. Exceptions (off unless hours are given): 2002-02-25, 2002-03-08.

## Resources

| Resource | Group | Rate | Cost per use |
| --- | --- | --- | --- |
| Иванов | Редактор раздела | 6.25 |  |
| Петров | Редактор раздела | 6.25 |  |
| Сидоров | Редактор раздела | 7.5 |  |
| Галкина | Отвественный секретарь | 3.12 |  |
| Уваров | Главный редактор | 12.5 |  |
| Васин | Технический редактор | 5 |  |
| Козлов | Технический редактор | 5 |  |
| Баранов | Корректор | 3.12 |  |
| Ураганов | Корректор | 3.12 |  |
| Еремин | Дизайнер | 7.5 |  |
| Жуков | Фотограф | 3.12 |  |
| Сергеева | Верстальщик | 3.75 |  |
| Улендеева | Верстальщик | 4.69 |  |
| Лимонов | Оператор Mac | 5 |  |
| Борисов | Оператор печатного аппарата | 3.12 |  |
| Семенов | Оператор Mac | 4.69 |  |
| Бурков | Оператор Mac | 3.12 |  |
| Тарарухин | Оператор печатного аппарата | 3.44 |  |
| Терехов | Оператор печатного аппарата | 2.5 |  |
| Фотомодель по контракту | Фотомодель | 50 | 100 |

## Schedule

| ID | WBS | Task | Type | Duration | Start | Finish | Predecessors | Complete | Remaining | Baseline start | Baseline finish | Baseline duration | Total slack | Free slack | Constraint | Resources | Work | Actual work | Cost | Baseline cost | Actual cost |
| --- | --- | --- | --- | --- | --- | --- | --- | --- | --- | --- | --- | --- | --- | --- | --- | --- | --- | --- | --- | --- | --- |
| 1 | PUBLAAA | **Планирование номера** |  | 12.88d | 2002-01-10 A | 2002-01-28 A |  | 100% |  | 2002-01-10 | 2002-01-25 | 12d |  |  |  |  | 105.94h | 105.94h | 765.85 | 620.04 | 765.85 |
| 2 | PUBLAAA-1 | Сбор предложений от авторов |  | 4.88d | 2002-01-10 A | 2002-01-16 A |  | 100% |  | 2002-01-10 | 2002-01-16 | 5d |  |  | start no earlier than 2002-01-07 | Иванов [17%]; Петров [25.6%]; Сидоров [20.5%] | 26h | 26h | 192.5 | 180 | 192.5 |
| 3 | PUBLAAA-2 | Подготовка плана номера |  | 2.88d | 2002-01-17 A | 2002-01-21 A | 2 | 100% |  | 2002-01-17 | 2002-01-21 | 3d |  |  |  | Иванов [20.9%]; Петров [21.7%]; Сидоров [20.9%]; Уваров [13%] | 17.6h | 17.6h | 134.75 | 126 | 134.75 |
| 4 | PUBLAAA-3 | Предварительная редколлегия |  | 0.88d | 2002-01-22 A | 2002-01-22 A | 3 | 100% |  | 2002-01-22 | 2002-01-22 | 1d |  |  |  | Иванов [57.1%]; Петров [31%]; Сидоров [31%]; Галкина [57.1%]; Уваров [71.4%] | 17.34h | 17.34h | 129.85 | 109.02 | 129.85 |
| 5 | PUBLAAA-4 | Доработка планов с учетом замечаний |  | 3d | 2002-01-23 A | 2002-01-25 A | 4 | 100% |  | 2002-01-23 | 2002-01-24 | 2d |  |  |  | Иванов [43.8%]; Петров [31.2%]; Сидоров [37.5%] | 27h | 27h | 180 | 96 | 180 |
| 6 | PUBLAAA-5 | Редколлегия |  | 0.88d | 2002-01-28 A | 2002-01-28 A | 5 | 100% |  | 2002-01-25 | 2002-01-25 | 1d |  |  |  | Иванов [57.1%]; Петров [42.9%]; Сидоров [42.9%]; Галкина [57.1%]; Уваров [57.1%] | 18h | 18h | 128.75 | 109.02 | 128.75 |
| 7 | PUBLAAA-6 | План номера утвержден | milestone | 0d | 2002-01-28 A | 2002-01-28 A | 6 | 100% |  | 2002-01-25 | 2002-01-25 | 0d |  |  |  |  |  |  |  |  |  |
| 8 | PUBLAAB | **Подготовка материалов** |  | 42d | 2002-01-29 A | 2002-03-29 |  | 32% | 28.45d | 2002-01-28 | 2002-03-13 | 33d | 5d |  |  |  | 686.4h | 116.4h | 5,912.5 | 4,358.5 | 1,677.5 |
| 9 | PUBLAAB-1 | **Подготовка обложки** |  | 37.88d | 2002-01-29 A | 2002-03-25 | 7 | 60% | 15.28d | 2002-01-28 | 2002-03-18 | 36d | 9.12d |  |  |  | 59.2h | 24h | 1,418 | 1,430.5 | 1,175 |
| 10 | PUBLAAB-1.1 | Отбор модели |  | 4.88d | 2002-01-29 A | 2002-02-04 A |  | 100% |  | 2002-01-28 | 2002-02-01 | 5d |  |  |  |  |  |  | 500 | 500 | 500 |
| 11 | PUBLAAB-1.2 | Фотосъемка модели |  | 4d | 2002-02-05 A | 2002-02-08 A | 10 | 100% |  | 2002-02-04 | 2002-02-06 | 3d |  |  |  | Фотомодель по контракту [37.5%]; Жуков [37.5%] | 24h | 24h | 675 | 687.5 | 675 |
| 12 | PUBLAAB-1.4 | Подготовка анонсов материалов номера для обложки |  | 3d | 2002-03-15 | 2002-03-20 | 21FS-4d |  |  | 2002-03-14 | 2002-03-18 | 3d | 9.12d | 0d |  | Сидоров [70%] | 13.6h |  | 102 | 102 |  |
| 13 | PUBLAAB-1.3 | Верстка обложки |  | 3d | 2002-03-20 | 2002-03-25 | 12 |  |  | 2002-02-07 | 2002-02-11 | 3d | 9.12d | 0d |  | Еремин [70%]; Жуков [20%] | 21.6h |  | 141 | 141 |  |
| 14 | PUBLAAB-1.5 | Обложка готова | milestone | 0d | 2002-03-25 | 2002-03-25 | 13 |  |  | 2002-03-18 | 2002-03-18 | 0d | 9.12d |  |  |  |  |  |  |  |  |
| 15 | 2.2 | **Подготовка текстов** |  | 42d | 2002-01-29 A | 2002-03-29 |  | 21% | 33d |  |  |  | 0d |  |  |  | 627.2h | 92.4h | 4,494.5 |  | 502.5 |
| 16 | 1 | Подготовка редакционных заданий |  | 2.88d | 2002-01-29 A | 2002-01-31 A | 7 | 100% |  | 2002-01-28 | 2002-01-30 | 3d |  |  |  | Иванов [52.2%]; Петров [60.9%]; Сидоров [52.2%]; Галкина [34.8%] | 46h | 46h | 277.5 | 262.5 | 277.5 |
| 17 | 2 | Рассылка заданий авторам |  | 1.88d | 2002-02-01 A | 2002-02-04 A | 16 | 100% |  | 2002-01-31 | 2002-01-31 | 1d |  |  |  | Галкина [160%] | 24h | 24h | 75 | 25 | 75 |
| 18 | 3 | Утверждение заданий |  | 3.33d | 2002-02-05 A | 2002-02-08 A | 17 | 100% |  | 2002-02-01 | 2002-02-05 | 3d |  |  |  | Иванов [31.3%]; Петров [31.3%]; Сидоров [30%]; Ураганов [30%] | 22.4h | 22.4h | 150 | 144 | 150 |
| 19 | 4 | Статьи в работе у авторов | milestone | 0d | 2002-02-08 A | 2002-02-08 A | 18 | 100% |  | 2002-02-05 | 2002-02-05 | 0d |  |  |  |  |  |  |  |  |  |
| 20 | 5 | Статьи поступили в редакцию | milestone | 0d | 2002-02-22 | 2002-02-22 | 19FS+10d |  |  | 2002-02-19 | 2002-02-19 | 0d | 0d |  |  |  |  |  | 1,000 | 1,000 |  |
| 21 | 6 | Редактирование материалов |  | 15.62d | 2002-02-22 | 2002-03-19 | 20 |  |  | 2002-02-20 | 2002-03-05 | 10d | 0d |  |  | Иванов [46.1%]; Петров [46.1%]; Сидоров [46.1%] | 154h |  | 1,025 | 960 |  |
| 22 | 7 | Техническое редактирование |  | 14d | 2002-03-12 | 2002-03-29 | 21SS+2d |  |  | 2002-02-22 | 2002-03-13 | 14d | 0d |  |  | Васин; Козлов; Галкина [50%]; Иванов [30%]; Петров [30%]; Сидоров [30%] | 380.8h |  | 1,967 | 1,967 |  |
| 23 | 15 | Тексты готовы | milestone | 0d | 2002-03-29 | 2002-03-29 | 22 |  |  |  |  |  | 0d |  | start no earlier than 2002-03-25 |  |  |  |  |  |  |
| 24 | PUBLAAB-8 | Подготовка материалов завершена | milestone | 0d | 2002-03-29 | 2002-03-29 | 22 |  |  | 2002-03-13 | 2002-03-13 | 0d | 0d |  |  |  |  |  |  |  |  |

| ID | WBS | Task | Type | Duration | Start | Finish | Predecessors | Baseline start | Baseline finish | Baseline duration | Total slack | Resources | Work | Cost | Baseline cost |
| --- | --- | --- | --- | --- | --- | --- | --- | --- | --- | --- | --- | --- | --- | --- | --- |
| 25 | PUBL3 | **Верстка журнала** |  | 18d | 2002-03-15 | 2002-04-09 |  | 2002-01-28 | 2002-03-22 | 40d | 0d |  | 521.6h | 2,195 | 3,613.5 |
| 26 | PUBL3-2 | Обработка текста и иллюстраций |  | 14d | 2002-03-15 | 2002-04-03 | 22SS+3d | 2002-02-27 | 2002-03-18 | 14d | 0d | Сергеева; Улендеева | 224h | 945 | 945 |
| 27 | PUBL3-3 | Вычитка |  | 14d | 2002-03-20 | 2002-04-08 | 26SS+3d | 2002-03-04 | 2002-03-21 | 14d | 0d | Баранов [50%]; Ураганов [50%] | 112h | 350 | 350 |
| 28 | PUBL3-4 | Сверка |  | 12d | 2002-03-25 | 2002-04-09 | 27SS+3d | 2002-03-07 | 2002-03-22 | 12d | 0d | Баранов [50%]; Ураганов [50%]; Иванов [30%]; Петров [30%]; Сидоров [30%] | 182.4h | 876 | 876 |
| 29 | PUBL3-5 | Подготовка оглавления |  | 2d | 2002-04-04 | 2002-04-05 | 26 | 2002-03-19 | 2002-03-20 | 2d | 0d | Сидоров [10%] | 1.6h | 12 | 12 |
| 30 | PUBL3-7 | Окончательная сборка |  | 2d | 2002-04-08 | 2002-04-09 | 29, 14 | 2002-03-19 | 2002-03-20 | 2d | 0d | Сидоров [10%] | 1.6h | 12 | 12 |
| 31 | PUBL3-6 | Номер сверстан | milestone | 0d | 2002-04-09 | 2002-04-09 | 30 | 2002-03-20 | 2002-03-20 | 0d | 0d |  |  |  |  |
| 32 | PUBLAAD | **Предпечатная подготовка** |  | 14.67d | 2002-04-09 | 2002-04-30 |  | 2002-03-20 | 2002-04-01 | 8d | 0d |  | 214.8h | 787.86 | 851.93 |
| 33 | PUBLAAD-1 | Конвертция сверстанного номера в формат Mac |  | 4.67d | 2002-04-09 | 2002-04-16 | 31 | 2002-03-20 | 2002-03-25 | 3d | 0d | Лимонов [16.7%]; Бурков [16.7%]; Семенов [16.7%] | 30h | 128.12 | 192.18 |
| 34 | PUBLAAD-2 | Цветоделение |  | 7d | 2002-04-16 | 2002-04-25 | 33 | 2002-03-25 | 2002-03-29 | 7d | 0d | Борисов [25%]; Тарарухин [25%]; Терехов [25%]; Бурков [20%]; Семенов [20%] | 64.4h | 214.37 | 214.37 |
| 35 | PUBLAAD-3 | Коррекция |  | 7d | 2002-04-17 | 2002-04-26 | 34SS+1d | 2002-03-26 | 2002-03-30 | 7d | 0d | Лимонов [25%]; Бурков [25%]; Семенов [25%] | 42h | 179.37 | 179.37 |
| 36 | PUBLAAD-4 | Вывод пленок |  | 7d | 2002-04-19 | 2002-04-30 | 35SS+2d | 2002-03-28 | 2002-04-01 | 7d | 0d | Лимонов [25%]; Бурков [25%]; Борисов [30%]; Тарарухин [30%]; Терехов [30%] | 78.4h | 266 | 266 |
| 37 | PUBLAAD-5 | Номер готов к передаче в типографию | milestone | 0d | 2002-04-30 | 2002-04-30 | 36 | 2002-04-01 | 2002-04-01 | 0d | 0d |  |  |  |  |
